# PIMS5

Schedule from MS Project, 2013-01-02 to 2013-07-03, status date 2010-12-09, 16 hours a day, costs in zł, A marks actual dates.
Project schedule
IPJ ZdAJ

## Calendars

- Standard: Mon-Fri 08:00-12:00, 13:00-17:00; Sat-Sun off.
- Standardowy: Mon-Fri 07:00-10:30, 11:00-14:00; Sat-Sun off.

## Resources

| Resource | Rate |
| --- | --- |
| TUD | 60 |
| WH105 | 160 |
| DMU70 | 160 |
| VF3YT | 160 |
| CTX510 | 160 |
| TUR | 65 |
| FUD | 65 |
| CPL1 | 140 |
| PA | 65 |
| P10 | 65 |
| PJ | 250 |
| TM | 65 |
| JZK | 120 |
| CPL2 | 140 |
| CPL4 | 120 |
| PM | 60 |
| CPL3 | 120 |

## Schedule

| ID | WBS | Task | Duration | Start | Finish | Predecessors | Complete | Remaining | Baseline start | Baseline finish | Baseline duration | Total slack | Free slack | Constraint | Calendar | Resources | Work | Actual work | Cost | Actual cost | Text1 |
| --- | --- | --- | --- | --- | --- | --- | --- | --- | --- | --- | --- | --- | --- | --- | --- | --- | --- | --- | --- | --- | --- |
| 1 | 1 | **Cavity L** | 65d? | 2013-01-02 A | 2013-07-03 |  | 27% | 47.37d? | 2011-01-17 | 2011-03-10 | 19.12d? | 0d |  |  | Standard |  | 2055.8h | 536h | 270,274.5 | 53,960 | SPLACPML0001 |
| 2 | 1.1 | **Ring wave guide** | 20d? | 2013-04-01 | 2013-06-07 |  |  |  | 2011-01-17 | 2011-02-21 | 12.62d? | 7.25d |  |  |  |  | 277.8h |  | 33,587 |  | SPLACPMZ0031 |
| 3 | 1.1.1 | Ring rough machining (+1 mm) mill | 0.33w | 2013-04-01 | 2013-04-04 |  |  |  | 2011-02-01 | 2011-02-02 | 0.12w? | 9.89d | 0.41d | start no earlier than 2013-04-01 |  | CPL1 | 26h |  | 3,640 |  |  |
| 4 | 1.1.2 | Cleaning | 0.08w | 2013-04-08 | 2013-04-08 | 3 |  |  | 2011-02-02 | 2011-02-02 | 0.03w? | 9.48d | 0.41d | finish no earlier than 2013-04-08 |  | PA | 6.5h |  | 422.5 |  |  |
| 5 | 1.1.3 | Stabilisation (heat treatment) | 0.24w | 2013-04-10 | 2013-04-12 | 4 |  |  | 2011-02-02 | 2011-02-03 | 0.1w? | 9.07d | 0d | finish no earlier than 2013-04-12 |  | PA | 19.5h |  | 1,267.5 |  |  |
| 6 | 1.1.4 | Ring rough machining (+0,5 mm) mill | 0.33w | 2013-04-15 | 2013-04-19 | 5 |  |  | 2011-02-07 | 2011-02-08 | 0.12w? | 9.07d | 0d | finish no earlier than 2013-04-18 |  | CPL1 | 26.4h |  | 3,696 |  |  |
| 7 | 1.1.5 | Cleaning | 0.08w? | 2013-04-19 | 2013-04-22 | 6 |  |  | 2011-02-08 | 2011-02-08 | 0.03w? | 9.07d | 0d |  |  | PA | 6.4h |  | 416 |  |  |
| 8 | 1.1.6 | Stabilisation (heat treatment) | 0.24w | 2013-04-22 | 2013-04-24 | 7 |  |  | 2011-02-08 | 2011-02-09 | 0.1w? | 9.07d | 0d |  |  | PA | 19.2h |  | 1,248 |  |  |
| 9 | 1.1.7 | Ring final machining mill | 0.33w | 2013-04-25 | 2013-05-01 | 8 |  |  | 2011-02-09 | 2011-02-11 | 0.2w? | 9.07d | 1.19d | finish no earlier than 2013-04-30 |  | CPL1 | 26.4h |  | 3,696 |  |  |
| 10 | 1.1.8 | Cleaning | 0.08w | 2013-05-06 | 2013-05-06 | 9 |  |  | 2011-02-15 | 2011-02-15 | 0.03w? | 7.88d | 0.41d | start no earlier than 2013-05-06 |  | PA | 6.4h |  | 416 |  |  |
| 11 | 1.1.9 | Metrology (the ring shall be unclamped to carry out the measurements) | 0.24w | 2013-05-08 | 2013-05-10 | 10 |  |  | 2011-02-15 | 2011-02-15 | 0.03w? | 7.47d | 0d | start no earlier than 2013-05-08 |  | PJ | 19.5h |  | 4,875 |  |  |
| 12 | 1.1.10 | Brazing of ports, fitting elbows, nipples and square flange | 0.81w | 2013-05-13 | 2013-05-24 | 11 |  |  | 2011-02-16 | 2011-02-16 | 0.05w? | 7.47d | 0d | finish no earlier than 2013-05-24 |  | PA | 65h |  | 4,225 |  |  |
| 13 | 1.1.11 | Leak test | 0.1w? | 2013-05-27 | 2013-05-28 | 12 |  |  | 2011-02-16 | 2011-02-17 | 0.1w? | 7.47d | 0d |  |  | PA | 8h |  | 520 |  |  |
| 14 | 1.1.12 | Water pressure test | 0.1w? | 2013-05-28 | 2013-05-29 | 13 |  |  | 2011-02-17 | 2011-02-18 | 0.1w? | 7.47d | 0.22d |  |  | PA | 8h |  | 520 |  |  |
| 15 | 1.1.13 | Metrology | 0.41w | 2013-05-30 | 2013-06-05 | 14 |  |  | 2011-02-18 | 2011-02-18 | 0.05w | 7.25d | 0d | finish no earlier than 2013-06-05 |  | PJ | 32.5h |  | 8,125 |  |  |
| 16 | 1.1.14 | Packing and Transport to CERN | 0.1w? | 2013-06-06 | 2013-06-07 | 15 |  |  | 2011-02-21 | 2011-02-21 | 0.03w? | 7.25d |  |  |  | TM | 8h |  | 520 |  |  |
| 17 | 1.2 | **Standard ring** | 51.94d? | 2013-01-02 A | 2013-07-01 |  | 49% | 26.39d? | 2011-02-01 | 2011-03-08 | 12.62d? | 0.5d |  |  |  |  | 488h | 240h | 49,520 | 17,840 | SPLACPMZ0033 |
| 18 | 1.2.1 | Ring rough machining (+1 mm) | 2w | 2013-01-02 A | 2013-01-30 A |  | 100% |  | 2011-02-01 | 2011-02-02 | 0.1w? |  |  | start no earlier than 2012-06-04 |  | TUD | 160h | 160h | 9,600 | 9,600 |  |
| 19 | 1.2.2 | Milling of port apertures according to the requirements by FZJ | 0.4w | 2013-01-30 A | 2013-02-06 A | 18 | 100% |  | 2011-02-02 | 2011-02-03 | 0.1w? |  |  |  |  | WH105 | 32h | 32h | 5,120 | 5,120 |  |
| 20 | 1.2.3 | Cleaning | 0.4w? | 2013-02-06 A | 2013-02-13 A | 19 | 100% |  | 2011-02-03 | 2011-02-04 | 0.1w? |  |  |  |  | PA | 32h | 32h | 2,080 | 2,080 |  |
| 21 | 1.2.4 | Packing and transport of rings and port tubes to FZJ | 0.2w? | 2013-02-13 A | 2013-02-18 A | 20 | 100% |  | 2011-02-04 | 2011-02-07 | 0.1w? |  |  |  |  | TM | 16h | 16h | 1,040 | 1,040 |  |
| 22 | 1.2.5 | EB welding | 1w | 2013-05-08 | 2013-05-24 | 21 |  |  | 2011-02-07 | 2011-02-28 | 1.5w | 0d |  | finish no earlier than 2013-05-24 |  | JZK | 80h |  | 9,600 |  |  |
| 23 | 1.2.6 | Port backing support machining | 0.4w | 2013-05-27 | 2013-05-31 | 22 |  |  | 2011-02-28 | 2011-02-28 | 0.03w | 0d |  |  |  | WH105 | 32h |  | 5,120 |  |  |
| 24 | 1.2.7 | X-ray testing | 0.2w? | 2013-05-31 | 2013-06-05 | 23 |  |  | 2011-02-28 | 2011-03-01 | 0.1w? | 0d |  |  |  | P10 | 16h |  | 1,040 |  |  |
| 25 | 1.2.8 | Leak test of ports | 0.1w? | 2013-06-05 | 2013-06-06 | 24 |  |  | 2011-03-01 | 2011-03-02 | 0.1w? | 0d |  |  |  | PA | 8h |  | 520 |  |  |
| 26 | 1.2.9 | Ring final machining | 0.5w | 2013-06-06 | 2013-06-14 | 25 |  |  | 2011-03-02 | 2011-03-03 | 0.1w? | 0d |  |  |  | CPL4 | 40h |  | 4,800 |  |  |
| 27 | 1.2.10 | Cleaning | 0.3w | 2013-06-14 | 2013-06-20 | 26 |  |  | 2011-03-03 | 2011-03-04 | 0.1w? | 0d |  |  |  | PA | 24h |  | 1,560 |  |  |
| 28 | 1.2.11 | Metrological report | 0.4w | 2013-06-20 | 2013-06-27 | 27 |  |  | 2011-03-04 | 2011-03-07 | 0.1w? | 0d |  |  |  | PJ | 32h |  | 8,000 |  |  |
| 29 | 1.2.12 | Packing and transport to CERN | 0.2w? | 2013-06-27 | 2013-07-01 | 28 |  |  | 2011-03-07 | 2011-03-08 | 0.1w? | 0.5d |  |  |  | TM | 16h |  | 1,040 |  |  |

| ID | WBS | Task | Duration | Start | Finish | Predecessors | Complete | Remaining | Baseline start | Baseline finish | Baseline duration | Total slack | Free slack | Constraint | Resources | Work | Actual work | Cost | Actual cost | Text1 |
| --- | --- | --- | --- | --- | --- | --- | --- | --- | --- | --- | --- | --- | --- | --- | --- | --- | --- | --- | --- | --- |
| 30 | 1.3 | **Ring pick-up** | 44.25d? | 2013-01-31 A | 2013-07-03 |  | 42% | 25.62d? | 2011-02-02 | 2011-03-10 | 13d? | 0d |  |  |  | 304h | 128h | 31,840 | 10,200 | SPLACPMZ0032 |
| 31 | 1.3.1 | Ring rough machining (+1 mm) | 1w | 2013-01-31 A | 2013-02-13 A | 18 | 100% |  | 2011-02-02 | 2011-02-03 | 0.1w? |  |  |  | TUD | 80h | 80h | 4,800 | 4,800 |  |
| 32 | 1.3.2 | Milling of port apertures according to the requirements by FZJ | 0.3w? | 2013-02-12 A | 2013-02-18 A | 31 | 100% |  | 2011-02-03 | 2011-02-04 | 0.1w? |  |  |  | WH105 | 24h | 24h | 3,840 | 3,840 |  |
| 33 | 1.3.3 | Cleaning | 0.2w? | 2013-02-19 A | 2013-02-21 A | 32FS+0.05w | 100% |  | 2011-02-04 | 2011-02-07 | 0.1w? |  |  |  | PA | 16h | 16h | 1,040 | 1,040 |  |
| 34 | 1.3.4 | Packing and transport of rings and port tubes to FZJ | 0.1w? | 2013-02-21 A | 2013-02-22 A | 33 | 100% |  | 2011-02-07 | 2011-02-08 | 0.1w? |  |  |  | TM | 8h | 8h | 520 | 520 |  |
| 35 | 1.3.5 | EB welding | 1w | 2013-05-08 | 2013-05-24 | 34, 22SS |  |  | 2011-02-08 | 2011-03-01 | 1.5w | 5d | 2d | finish no earlier than 2013-05-24 | JZK | 80h |  | 9,600 |  |  |
| 36 | 1.3.6 | Port backing support machining | 0.2w | 2013-05-31 | 2013-06-05 | 23, 35 |  |  | 2011-03-01 | 2011-03-02 | 0.1w? | 3d | 0d |  | WH105 | 16h |  | 2,560 |  |  |
| 37 | 1.3.7 | X-ray testing | 0.1w? | 2013-06-05 | 2013-06-06 | 36 |  |  | 2011-03-02 | 2011-03-03 | 0.1w? | 3d | 0d |  | P10 | 8h |  | 520 |  |  |
| 38 | 1.3.8 | Leak test of ports | 0.1w? | 2013-06-06 | 2013-06-07 | 37 |  |  | 2011-03-03 | 2011-03-04 | 0.1w? | 3d | 2d |  | PA | 8h |  | 520 |  |  |
| 39 | 1.3.9 | Ring final machining | 0.3w | 2013-06-14 | 2013-06-20 | 38, 26 |  |  | 2011-03-04 | 2011-03-07 | 0.1w? | 1d | 0d |  | CPL4 | 24h |  | 2,880 |  |  |
| 40 | 1.3.10 | Cleaning | 0.2w | 2013-06-20 | 2013-06-24 | 39 |  |  | 2011-03-07 | 2011-03-08 | 0.1w? | 1d |  |  | PA | 16h |  | 1,040 |  |  |
| 41 | 1.3.11 | Metrological report | 0.2w | 2013-06-27 | 2013-07-01 | 40, 28 |  |  | 2011-03-08 | 2011-03-09 | 0.1w? | 0d |  |  | PJ | 16h |  | 4,000 |  |  |
| 42 | 1.3.12 | Packing and transport to CERN | 0.1w? | 2013-07-01 | 2013-07-03 | 41 |  |  | 2011-03-09 | 2011-03-10 | 0.1w? | 0d |  |  | TM | 8h |  | 520 |  |  |
| 43 | 1.4 | **End disc** | 27.62d? | 2013-01-02 A | 2013-04-08 |  | 12% | 24.18d? | 2011-01-17 | 2011-02-10 | 9.5d? | 24.81d |  |  |  | 192.5h | 24h | 28,547.5 | 3,360 | SPLACPMK0002 |
| 44 | 1.4.1 | Disc rough machining including coupling slots (all +1 mm) | 0.3w? | 2013-01-02 A | 2013-01-08 A |  | 100% |  | 2011-01-31 | 2011-01-31 | 0.1w? |  |  |  | CPL2 | 24h | 24h | 3,360 | 3,360 |  |
| 45 | 1.4.2 | Drilling of cooling circuits | 0.16w | 2013-03-04 | 2013-03-05 |  |  |  | 2011-02-01 | 2011-02-01 | 0.1w? | 24.84d | 0d | start no earlier than 2013-03-04 | CPL1 | 13h |  | 1,820 |  |  |
| 46 | 1.4.3 | Installation of temporary threaded plugs to protect cooling circuits during final machining and cleaning | 0.08w? | 2013-03-06 | 2013-03-06 | 45 |  |  | 2011-02-02 | 2011-02-02 | 0.1w? | 24.84d | 0d | start no earlier than 2013-03-05 | PM | 6.5h |  | 390 |  |  |
| 47 | 1.4.4 | Final machining | 0.81w | 2013-03-07 | 2013-03-20 | 46 |  |  | 2011-02-03 | 2011-02-03 | 0.1w? | 24.84d | 0d |  | CPL2 | 65h |  | 9,100 |  |  |
| 48 | 1.4.5 | Cleaning | 0.2w? | 2013-03-21 | 2013-03-25 | 47 |  |  | 2011-02-04 | 2011-02-04 | 0.1w? | 24.84d | 0d | start no earlier than 2013-03-19 | PA | 16h |  | 1,040 |  |  |
| 49 | 1.4.6 | Leak test of cooling circuits | 0.1w? | 2013-03-25 | 2013-03-26 | 48 |  |  | 2011-02-07 | 2011-02-07 | 0.1w? | 24.84d | 0d |  | PA | 8h |  | 520 |  |  |
| 50 | 1.4.7 | Pressure test of the cooling circuits | 0.1w | 2013-03-26 | 2013-03-27 | 49 |  |  | 2011-02-08 | 2011-02-08 | 0.1w? | 24.84d | 0.03d |  | PA | 8h |  | 520 |  |  |
| 51 | 1.4.8 | Metrology control (the disc shall be unclamped to carry out the measurements) | 0.57w | 2013-03-28 | 2013-04-05 | 50 |  |  | 2011-02-09 | 2011-02-09 | 0.1w? | 24.81d | 0d | start no earlier than 2013-03-28 | PJ | 45.5h |  | 11,375 |  |  |
| 52 | 1.4.9 | Packing and Transport to CERN | 0.08w | 2013-04-08 | 2013-04-08 | 51 |  |  | 2011-02-10 | 2011-02-10 | 0.1w? | 24.81d |  |  | TM | 6.5h |  | 422.5 |  |  |
| 53 | 1.5 | **Standard disc** | 40.72d? | 2013-01-02 A | 2013-05-22 |  | 24% | 31.04d? | 2011-02-01 | 2011-02-11 | 4.5d? | 12.12d |  |  |  | 585h | 120h | 99,955 | 19,200 | SPLACPMK0003 |
| 54 | 1.5.1 | Disc rough machining including coupling slots (all +1 mm) | 1.5w | 2013-01-02 A | 2013-01-28 A |  | 100% |  | 2011-02-01 | 2011-02-01 | 0.1w? |  |  |  | VF3YT | 120h | 120h | 19,200 | 19,200 |  |
| 55 | 1.5.2 | Drilling of cooling circuits | 0.41w | 2013-03-04 | 2013-03-08 | 54 |  |  | 2011-02-02 | 2011-02-02 | 0.1w? | 12.84d | 0d | finish no earlier than 2013-03-08 | WH105 | 32.5h |  | 5,200 |  |  |
| 56 | 1.5.3 | Installation of temporary threaded plugs to protect cooling circuits during final machining and cleaning | 0.16w | 2013-03-11 | 2013-03-12 | 55 |  |  | 2011-02-03 | 2011-02-03 | 0.1w? | 12.84d | 0.41d |  | PM | 13h |  | 780 |  |  |
| 57 | 1.5.4 | Disc semi machining (all +0,3mm) | 0.73w | 2013-03-12 | 2013-03-22 | 56SS |  |  | 2011-02-01 | 2011-02-01 | 0.1w? | 12.44d | 0d | finish no earlier than 2013-03-22 | DMU70 | 58.5h |  | 9,360 |  |  |
| 58 | 1.5.5 | Final machining | 1.62w | 2013-03-25 | 2013-04-19 | 57 |  |  | 2011-02-04 | 2011-02-04 | 0.1w? | 12.44d | 0d |  | DMU70 | 130h |  | 20,800 |  |  |
| 59 | 1.5.6 | Cleaning | 0.24w | 2013-04-18 | 2013-04-23 | 58FF+0.1w |  |  | 2011-02-07 | 2011-02-07 | 0.1w? | 12.44d | 0.31d |  | PA | 19.5h |  | 1,267.5 |  |  |
| 60 | 1.5.7 | Leak test of cooling circuits | 0.24w? | 2013-04-24 | 2013-04-26 | 59 |  |  | 2011-02-08 | 2011-02-08 | 0.1w? | 12.12d | 0d | start no earlier than 2013-04-24 | PA | 19.5h |  | 1,267.5 |  |  |
| 61 | 1.5.8 | Pressure test of the cooling circuits | 0.2w? | 2013-04-29 | 2013-05-01 | 60 |  |  | 2011-02-09 | 2011-02-09 | 0.1w? | 12.12d | 0d |  | PA | 16h |  | 1,040 |  |  |
| 62 | 1.5.9 | Metrology control (the disc shall be unclamped to carry out the measurements) | 1w | 2013-05-01 | 2013-05-17 | 61 |  |  | 2011-02-10 | 2011-02-10 | 0.1w? | 12.12d | 0d |  | PJ [200%] | 160h |  | 40,000 |  |  |
| 63 | 1.5.10 | Packing and Transport to CERN | 0.2w? | 2013-05-17 | 2013-05-22 | 62 |  |  | 2011-02-11 | 2011-02-11 | 0.1w? | 12.12d |  |  | TM | 16h |  | 1,040 |  |  |

| ID | WBS | Task | Duration | Start | Finish | Predecessors | Complete | Remaining | Baseline start | Baseline finish | Baseline duration | Total slack | Free slack | Constraint | Resources | Work | Actual work | Cost | Actual cost | Text1 |
| --- | --- | --- | --- | --- | --- | --- | --- | --- | --- | --- | --- | --- | --- | --- | --- | --- | --- | --- | --- | --- |
| 64 | 1.6 | **Central disk** | 30.62d? | 2013-01-02 A | 2013-04-18 |  | 12% | 27.1d? | 2011-02-02 | 2011-02-14 | 4.5d? | 21.81d |  |  |  | 208.5h | 24h | 26,825 | 3,360 | SPLACPMK0004 |
| 65 | 1.6.1 | Disc rough machining including coupling slots (all +1 mm) | 0.3w | 2013-01-02 A | 2013-01-08 A |  | 100% |  | 2011-02-02 | 2011-02-02 | 0.1w? |  |  |  | CPL2 | 24h | 24h | 3,360 | 3,360 |  |
| 66 | 1.6.2 | Drilling of cooling circuits | 0.33w | 2013-03-11 | 2013-03-14 |  |  |  | 2011-02-03 | 2011-02-03 | 0.1w? | 21.81d | 0d | start no earlier than 2013-03-11 | CPL1 | 26h |  | 3,640 |  |  |
| 67 | 1.6.3 | Installation of temporary threaded plugs to protect cooling circuits during final machining and cleaning | 0.16w | 2013-03-15 | 2013-03-18 | 66 |  |  | 2011-02-04 | 2011-02-04 | 0.1w? | 21.81d | 0d | start no earlier than 2013-03-14 | PM | 13h |  | 780 |  |  |
| 68 | 1.6.4 | Final machining | 0.81w | 2013-03-19 | 2013-04-01 | 67 |  |  | 2011-02-07 | 2011-02-07 | 0.1w? | 21.81d | 0d |  | CPL3 | 65h |  | 7,800 |  |  |
| 69 | 1.6.5 | Cleaning | 0.2w? | 2013-04-02 | 2013-04-04 | 68 |  |  | 2011-02-08 | 2011-02-08 | 0.1w? | 21.81d | 0d |  | PA | 16h |  | 1,040 |  |  |
| 70 | 1.6.6 | Leak test of cooling circuits | 0.1w? | 2013-04-04 | 2013-04-05 | 69 |  |  | 2011-02-09 | 2011-02-09 | 0.1w? | 21.81d | 0d |  | PA | 8h |  | 520 |  |  |
| 71 | 1.6.7 | Pressure test of the cooling circuits | 0.1w? | 2013-04-05 | 2013-04-08 | 70 |  |  | 2011-02-10 | 2011-02-10 | 0.1w? | 21.81d | 0d |  | PA | 8h |  | 520 |  |  |
| 72 | 1.6.8 | Metrology control (the disc shall be unclamped to carry out the measurements) | 0.41w | 2013-04-08 | 2013-04-15 | 71 |  |  | 2011-02-11 | 2011-02-11 | 0.1w? | 21.81d | 0d |  | PJ | 32.5h |  | 8,125 |  |  |
| 73 | 1.6.9 | Packing and Transport to CERN | 0.2w? | 2013-04-15 | 2013-04-18 | 72 |  |  | 2011-02-14 | 2011-02-14 | 0.1w? | 21.81d |  |  | TM | 16h |  | 1,040 |  |  |
